# SPEAR3 Commissioning

Schedule from MS Project, 2003-12-08 to 2004-03-07.
SSRL

## Calendars

- Standard: Mon-Sun 08:00-12:00, 13:00-17:00. Exceptions (off unless hours are given): 2003-12-24 to 2003-12-26, 2003-12-27 to 2003-12-28 08:00-12:00, 13:00-17:00, 2004-01-01.

## Resources

| Resource |
| --- |
| EDM Tech |
| SLAC EE |
| DB Elect |
| EDM EE |
| SLAC Tech |
| Elect Tech |
| Elect Engr |
| Contractor EE |
| Mech Tech |
| DB Plumber |

## Schedule

| ID | WBS | Task | Type | Duration | Start | Finish | Predecessors | Baseline start | Baseline finish | Baseline duration | Total slack | Free slack | Constraint |
| --- | --- | --- | --- | --- | --- | --- | --- | --- | --- | --- | --- | --- | --- |
| 1 | 1 | **Commissioning with beam** |  | 87d | 2003-12-08 08:00 | 2004-03-07 17:00 |  | 2003-11-05 17:00 | 2003-11-05 17:00 | 54d | 0d |  | start no earlier than 2003-12-08 08:00 |
| 2 | 1.1 | **Establish BTS beam** |  | 1.5d | 2003-12-08 08:00 | 2003-12-09 12:00 |  | 2003-11-05 08:00 | 2003-11-06 12:00 | 1.5d | 0.75d | 0d |  |
| 3 | 1.1.1 | Electrons at injection septum |  | 0.5d | 2003-12-08 08:00 | 2003-12-08 12:00 |  | 2003-11-05 08:00 | 2003-11-05 12:00 | 0.5d | 0.75d | 0d |  |
| 4 | 1.1.2 | Characterize BTS optics |  | 0.5d | 2003-12-08 13:00 | 2003-12-08 17:00 | 3 | 2003-11-05 13:00 | 2003-11-05 17:00 | 0.5d | 0.75d | 0d |  |
| 5 | 1.1.3 | Check injection kicker timing |  | 0.5d | 2003-12-09 08:00 | 2003-12-09 12:00 | 4 | 2003-11-06 08:00 | 2003-11-06 12:00 | 0.5d | 0.75d |  |  |
| 6 | 1.2 | **Single turn** |  | 2.5d | 2003-12-09 13:00 | 2003-12-11 17:00 | 2 | 2003-11-06 13:00 | 2003-11-08 17:00 | 2.5d | 0.75d | 0d |  |
| 7 | 1.2.1 | Find beam on strip line |  | 0.25d | 2003-12-09 13:00 | 2003-12-09 15:00 |  | 2003-11-06 13:00 | 2003-11-06 15:00 | 0.25d | 0.75d | 0d |  |
| 8 | 1.2.2 | Measure beam losses on LIONs |  | 0.5d | 2003-12-09 15:00 | 2003-12-10 10:00 | 7 | 2003-11-06 15:00 | 2003-11-07 10:00 | 0.5d | 0.75d | 0d |  |
| 9 | 1.2.3 | Adjust harmonic orbit knobs |  | 0.25d | 2003-12-10 10:00 | 2003-12-10 12:00 | 8 | 2003-11-07 10:00 | 2003-11-07 12:00 | 0.25d | 0.75d | 0d |  |
| 10 | 1.2.4 | Start commissioning single-turn BPMs |  | 1.25d | 2003-12-10 13:00 | 2003-12-11 15:00 | 9 | 2003-11-07 13:00 | 2003-11-08 15:00 | 1.25d | 0.75d | 0d |  |
| 11 | 1.2.5 | Verify integer tunes |  | 0.25d | 2003-12-11 15:00 | 2003-12-11 17:00 | 10 | 2003-11-08 15:00 | 2003-11-08 17:00 | 0.25d | 0.75d |  |  |
| 12 | 1.3 | RP/OHP BTS raft radiation survey |  | 0.5d | 2003-12-12 08:00 | 2003-12-12 12:00 | 6 | 2003-12-12 08:00 | 2003-12-12 12:00 | 0.5d | 0.75d | 0d |  |
| 13 | 1.4 | **Capture single injector pulse** |  | 2d | 2003-12-12 13:00 | 2003-12-14 12:00 | 12 | 2003-11-09 08:00 | 2003-11-10 17:00 | 2d | 0.75d | 0d |  |
| 14 | 1.4.1 | Establish many turns |  | 1.4d | 2003-12-12 13:00 | 2003-12-13 16:12 |  | 2003-11-09 08:00 | 2003-11-10 11:12 | 1.4d | 0.75d | 0d |  |
| 15 | 1.4.2 | RF capture/phasing |  | 0.25d | 2003-12-13 16:12 | 2003-12-14 09:12 | 14 | 2003-11-10 11:12 | 2003-11-10 14:12 | 0.25d | 0.75d | 0d |  |
| 16 | 1.4.3 | Turn on sextupoles |  | 0.25d | 2003-12-14 09:12 | 2003-12-14 11:12 | 15 | 2003-11-10 14:12 | 2003-11-10 16:12 | 0.25d | 0.75d | 0d |  |
| 17 | 1.4.4 | Beam stopper test |  | 0.1d | 2003-12-14 11:12 | 2003-12-14 12:00 | 16 | 2003-11-10 16:12 | 2003-11-10 17:00 | 0.1d | 0.75d |  |  |
| 18 | 1.5 | **Establish accumulation** |  | 3.75d | 2003-12-14 13:00 | 2003-12-18 10:00 | 13 | 2003-11-11 08:00 | 2003-11-13 17:00 | 3d | 0.75d | 0d |  |
| 19 | 1.5.1 | Measure kicker bump closure |  | 0.25d | 2003-12-14 13:00 | 2003-12-14 15:00 |  | 2003-11-11 08:00 | 2003-11-11 10:00 | 0.25d | 0.75d | 0d |  |
| 20 | 1.5.2 | Measure DC injection bump closure |  | 0.25d | 2003-12-14 15:00 | 2003-12-14 17:00 | 19 | 2003-11-11 10:00 | 2003-11-11 12:00 | 0.25d | 0.75d | 0d |  |
| 21 | 1.5.3 | Establish multibunch filling |  | 2d | 2003-12-15 08:00 | 2003-12-16 17:00 | 20 | 2003-11-11 13:00 | 2003-11-13 12:00 | 2d | 0.75d | 0d |  |
| 22 | 1.5.4 | Measure injection efficiency |  | 0.25d | 2003-12-17 08:00 | 2003-12-17 10:00 | 21 | 2003-11-13 13:00 | 2003-11-13 15:00 | 0.25d | 0.75d | 0d |  |
| 23 | 1.5.5 | Store 10 mA | milestone | 0d | 2003-12-17 10:00 | 2003-12-17 10:00 | 22 | 2003-11-13 15:00 | 2003-11-13 15:00 | 0d? | 0.75d | 0d |  |
| 24 | 1.5.6 | Beamline first light |  | 1d | 2003-12-17 10:00 | 2003-12-18 10:00 | 23 | 2003-11-13 15:00 | 2003-11-13 17:00 | 0.25d | 0.75d |  |  |

| ID | WBS | Task | Duration | Start | Finish | Predecessors | Baseline start | Baseline finish | Baseline duration | Total slack | Free slack |
| --- | --- | --- | --- | --- | --- | --- | --- | --- | --- | --- | --- |
| 25 | 1.6 | **Commission diagnostics** | 10.5d | 2003-12-18 10:00 | 2003-12-31 15:00 | 18 | 2003-11-14 08:00 | 2003-11-19 12:00 | 5.5d | 0.75d | 0d |
| 26 | 1.6.1 | Tune monitor | 0.25d | 2003-12-18 10:00 | 2003-12-18 12:00 |  | 2003-11-14 08:00 | 2003-11-14 10:00 | 0.25d | 0.75d | 0d |
| 27 | 1.6.2 | DCCT | 0.25d | 2003-12-18 13:00 | 2003-12-18 15:00 | 26 | 2003-11-14 10:00 | 2003-11-14 12:00 | 0.25d | 0.75d | 0d |
| 28 | 1.6.3 | Bergoz BPMs | 4d | 2003-12-18 15:00 | 2003-12-22 15:00 | 27 | 2003-11-14 13:00 | 2003-11-16 12:00 | 2d | 0.75d | 0d |
| 29 | 1.6.4 | Test dispersion-leak optics | 1d | 2003-12-22 15:00 | 2003-12-23 15:00 | 28 | 2003-12-22 15:00 | 2003-12-23 15:00 | 1d | 0.75d | 0d |
| 30 | 1.6.5 | Test QMS system | 2d | 2003-12-23 15:00 | 2003-12-28 15:00 | 29 | 2003-11-16 13:00 | 2003-11-18 12:00 | 2d | 0.75d | 0d |
| 31 | 1.6.6 | SLM | 1d | 2003-12-28 15:00 | 2003-12-29 15:00 | 30 | 2003-11-18 13:00 | 2003-11-19 12:00 | 1d | 0.75d | 0d |
| 32 | 1.6.7 | Current interlock | 1d | 2003-12-29 15:00 | 2003-12-30 15:00 | 31 | 2003-12-29 15:00 | 2003-12-30 15:00 | 1d | 0.75d | 0d |
| 33 | 1.6.8 | LIONs | 1d | 2003-12-30 15:00 | 2003-12-31 15:00 | 32 | 2003-12-30 15:00 | 2003-12-31 15:00 | 1d | 0.75d |  |
| 34 | 1.7 | **Beam steering, 1** | 11.5d | 2003-12-31 15:00 | 2004-01-13 10:00 | 25 | 2003-12-09 08:00 | 2004-01-04 12:00 | 17.5d | 0.75d | 0d |
| 35 | 1.7.1 | Standardization speed studies | 0.5d | 2003-12-31 15:00 | 2004-01-02 10:00 |  | 2003-12-31 15:00 | 2004-01-02 15:00 | 1d | 0.75d | 0d |
| 36 | 1.7.2 | Quad centering | 4d | 2004-01-02 10:00 | 2004-01-06 10:00 | 35 | 2003-12-09 08:00 | 2003-12-10 17:00 | 2d | 0.75d | 0d |
| 37 | 1.7.3 | Optimize rf frequency | 0.25d | 2004-01-06 10:00 | 2004-01-06 12:00 | 36 | 2003-12-11 08:00 | 2003-12-11 10:00 | 0.25d | 0.75d | 0d |
| 38 | 1.7.4 | Orbit correction | 2.25d | 2004-01-06 13:00 | 2004-01-08 15:00 | 37 | 2003-12-11 10:00 | 2003-12-11 12:00 | 0.25d | 0.75d | 0d |
| 39 | 1.7.5 | Commission orbit interlock | 4d | 2004-01-08 15:00 | 2004-01-12 15:00 | 38 | 2003-11-20 13:00 | 2003-11-25 12:00 | 5d | 0.75d | 0d |
| 40 | 1.7.6 | TSP sublimation with beam | 0.5d | 2004-01-12 15:00 | 2004-01-13 10:00 | 39 |  |  |  | 0.75d |  |
| 41 | 1.8 | **Characterize/correct optics, IDs open** | 10d | 2004-01-13 10:00 | 2004-01-23 10:00 | 34 | 2003-11-25 13:00 | 2003-12-02 17:00 | 6.5d | 0.75d | 0d |
| 42 | 1.8.1 | Measure x,y,s tunes | 0.5d | 2004-01-13 10:00 | 2004-01-13 15:00 |  | 2003-11-25 13:00 | 2003-11-25 17:00 | 0.5d | 0.75d | 0d |
| 43 | 1.8.2 | Measure betas at quadrupoles | 0.25d | 2004-01-13 15:00 | 2004-01-13 17:00 | 42 | 2003-11-26 08:00 | 2003-11-26 10:00 | 0.25d | 0.75d | 0d |
| 44 | 1.8.3 | Measure dispersion | 0.25d | 2004-01-14 08:00 | 2004-01-14 10:00 | 43 | 2003-11-26 10:00 | 2003-11-26 12:00 | 0.25d | 0.75d | 0d |
| 45 | 1.8.4 | Measure corrected chromaticity | 0.25d | 2004-01-14 10:00 | 2004-01-14 12:00 | 44 | 2003-11-26 13:00 | 2003-11-26 15:00 | 0.25d | 0.75d | 0d |
| 46 | 1.8.5 | Measure natural chromaticity | 0.5d | 2004-01-14 13:00 | 2004-01-14 17:00 | 45 | 2003-11-26 15:00 | 2003-11-28 10:00 | 0.5d | 0.75d | 0d |
| 47 | 1.8.6 | Measure lifetime | 1d | 2004-01-15 08:00 | 2004-01-15 17:00 | 46 | 2003-11-28 10:00 | 2003-11-29 10:00 | 1d | 0.75d | 0d |
| 48 | 1.8.7 | Measure orbit response matrix | 2d | 2004-01-16 08:00 | 2004-01-17 17:00 | 47 | 2003-11-29 10:00 | 2003-11-30 10:00 | 1d | 0.75d | 0d |
| 49 | 1.8.8 | Measure x-y tune split | 0.25d | 2004-01-18 08:00 | 2004-01-18 10:00 | 48 | 2003-11-30 10:00 | 2003-11-30 12:00 | 0.25d | 0.75d | 0d |
| 50 | 1.8.9 | Initial coupling correction | 1d | 2004-01-18 10:00 | 2004-01-19 10:00 | 49 | 2003-11-30 13:00 | 2003-11-30 15:00 | 0.25d | 0.75d | 0d |
| 51 | 1.8.10 | Inter-cavity rf phasing | 0.25d | 2004-01-19 10:00 | 2004-01-19 12:00 | 50 | 2003-11-30 15:00 | 2003-11-30 17:00 | 0.25d | 0.75d | 0d |
| 52 | 1.8.11 | Measure bunch length | 0.25d | 2004-01-19 13:00 | 2004-01-19 15:00 | 51 | 2003-12-01 08:00 | 2003-12-01 10:00 | 0.25d | 0.75d | 0d |
| 53 | 1.8.12 | Measure momentum compaction | 0.25d | 2004-01-19 15:00 | 2004-01-19 17:00 | 52 | 2003-12-01 10:00 | 2003-12-01 12:00 | 0.25d | 0.75d | 0d |
| 54 | 1.8.13 | Measure energy aperture | 1d | 2004-01-20 08:00 | 2004-01-20 17:00 | 53 | 2003-12-01 13:00 | 2003-12-01 17:00 | 0.5d | 0.75d | 0d |
| 55 | 1.8.14 | Measure damping time | 0.25d | 2004-01-21 08:00 | 2004-01-21 10:00 | 54 | 2003-12-02 08:00 | 2003-12-02 10:00 | 0.25d | 0.75d | 0d |
| 56 | 1.8.15 | Measure tune shift with amplitude | 1d | 2004-01-21 10:00 | 2004-01-22 10:00 | 55 | 2003-12-02 10:00 | 2003-12-02 12:00 | 0.25d | 0.75d | 0d |
| 57 | 1.8.16 | Measure dynamic aperture | 1d | 2004-01-22 10:00 | 2004-01-23 10:00 | 56 | 2003-12-02 13:00 | 2003-12-02 17:00 | 0.5d | 0.75d |  |

Notes:
- 35: Vary ramp speed, Ncycles, pause time; measure Dorbit, Dtune
- 40: sublimating the TSPs takes ~3 hours. See what effect it has on stored beam.
- 54: First just rf frequency limits / Lifetime vs. rf voltage (as w/ ALS) / Later measure loss vs. kick amplitude vs. rf frequency (as w/ ALS)
- 57: vs. rf frequency

| ID | WBS | Task | Duration | Start | Finish | Predecessors | Baseline start | Baseline finish | Baseline duration | Total slack | Free slack | Constraint |
| --- | --- | --- | --- | --- | --- | --- | --- | --- | --- | --- | --- | --- |
| 58 | 1.9 | **Close IDs** | 6d | 2004-01-23 10:00 | 2004-01-29 10:00 | 41 | 2003-12-03 08:00 | 2003-12-08 17:00 | 6d | 0.75d | 0d |  |
| 59 | 1.9.1 | Check ID trim tables | 0.5d | 2004-01-23 10:00 | 2004-01-23 15:00 |  | 2003-12-03 08:00 | 2003-12-03 12:00 | 0.5d | 0.75d | 0d |  |
| 60 | 1.9.2 | Develop trim table for new BL4 | 1d | 2004-01-23 15:00 | 2004-01-24 15:00 | 59 | 2003-12-03 13:00 | 2003-12-04 12:00 | 1d | 0.75d | 0d |  |
| 61 | 1.9.3 | Check ID focusing compensation | 1d | 2004-01-24 15:00 | 2004-01-25 15:00 | 60 | 2003-12-04 13:00 | 2003-12-05 12:00 | 1d | 0.75d | 0d |  |
| 62 | 1.9.4 | Open available beamlines | 0.5d | 2004-01-25 15:00 | 2004-01-26 10:00 | 61 | 2003-12-05 13:00 | 2003-12-05 17:00 | 0.5d | 0.75d | 0d |  |
| 63 | 1.9.5 | Characterize/correct optics, IDs closed | 3d | 2004-01-26 10:00 | 2004-01-29 10:00 | 62 | 2003-12-06 08:00 | 2003-12-08 17:00 | 3d | 0.75d |  |  |
| 64 | 1.10 | **Beam steering, 2** | 12d | 2004-01-29 10:00 | 2004-02-10 10:00 | 58 | 2003-12-09 08:00 | 2004-01-04 12:00 | 17.5d | 0.75d | 0d |  |
| 65 | 1.10.1 | Slow orbit feedback | 1d | 2004-01-29 10:00 | 2004-01-30 10:00 |  | 2003-12-11 13:00 | 2003-12-12 12:00 | 1d | 0.75d | 0d |  |
| 66 | 1.10.2 | (Test fast orbit feedback) | 1d | 2004-01-30 10:00 | 2004-01-31 10:00 | 65 | 2003-12-12 13:00 | 2003-12-13 12:00 | 1d | 0.75d | 0d |  |
| 67 | 1.10.3 | Beam bump probe of physical aperture | 1d | 2004-01-31 10:00 | 2004-02-01 10:00 | 66 | 2003-12-13 13:00 | 2003-12-14 12:00 | 1d | 0.75d | 0d |  |
| 68 | 1.10.4 | Beam stability characterization | 0.5d | 2004-02-01 10:00 | 2004-02-01 15:00 | 67 | 2003-12-14 13:00 | 2003-12-14 17:00 | 0.5d | 0.75d | 0d |  |
| 69 | 1.10.5 | Measure vacuum chamber stability | 0.5d | 2004-02-01 15:00 | 2004-02-02 10:00 | 68 | 2003-12-15 08:00 | 2003-12-15 12:00 | 0.5d | 0.75d | 0d |  |
| 70 | 1.10.6 | Beamline steering | 8d | 2004-02-02 10:00 | 2004-02-10 10:00 | 69 | 2004-02-02 10:00 | 2004-02-10 10:00 | 8d | 0.75d |  |  |
| 71 | 1.11 | RP/OHP ring radiation survey, 3*16 hour shifts | 3d | 2004-02-10 10:00 | 2004-02-13 10:00 | 64 | 2004-02-10 10:00 | 2004-02-13 10:00 | 3d | 0.75d | 0d |  |
| 72 | 1.12 | **Characterize impedance** | 2d | 2004-02-13 10:00 | 2004-02-15 10:00 | 71 | 2004-01-04 13:00 | 2004-01-07 12:00 | 3d | 0.75d | 0d |  |
| 73 | 1.12.1 | Bunch length vs. bunch current | 0.25d | 2004-02-13 10:00 | 2004-02-13 12:00 |  | 2004-01-04 13:00 | 2004-01-04 15:00 | 0.25d | 0.75d | 0d | start no earlier than 2003-12-07 08:00 |
| 74 | 1.12.2 | Tune vs. bunch current | 0.25d | 2004-02-13 13:00 | 2004-02-13 15:00 | 73 | 2004-01-04 15:00 | 2004-01-04 17:00 | 0.25d | 0.75d | 0d |  |
| 75 | 1.12.3 | Phase advance vs. bunch current | 0.25d | 2004-02-13 15:00 | 2004-02-13 17:00 | 74 | 2004-01-05 08:00 | 2004-01-05 10:00 | 0.25d | 0.75d | 0d |  |
| 76 | 1.12.4 | Synchronous phase vs. bunch current | 0.25d | 2004-02-14 08:00 | 2004-02-14 10:00 | 75 | 2004-01-05 10:00 | 2004-01-05 12:00 | 0.25d | 0.75d | 0d |  |
| 77 | 1.12.5 | Optimize fill pattern | 1d | 2004-02-14 10:00 | 2004-02-15 10:00 | 76 | 2004-01-05 13:00 | 2004-01-07 12:00 | 2d | 0.75d |  |  |
| 78 | 1.13 | Contingency for hardware repair | 21d | 2004-02-15 10:00 | 2004-03-07 10:00 | 72 | 2004-01-08 08:00 | 2004-01-31 17:00 | 23d | 0.75d |  | finish no earlier than 2004-02-29 17:00 |
| 79 | 1.14 | Commissioning beamlines with local users | 21d | 2004-02-15 10:00 | 2004-03-07 10:00 | 72 | 2004-01-08 08:00 | 2004-01-31 17:00 | 23d | 0.75d |  | finish no earlier than 2004-02-29 17:00 |
| 80 | 1.15 | Maintenance, 7 days | 7d | 2004-02-23 08:00 | 2004-02-29 17:00 |  | 2004-02-23 08:00 | 2004-02-29 17:00 | 7d | 7d |  | start no earlier than 2004-02-23 08:00 |
| 81 | 1.16 | RP/OHP BL radiation surveys (4*16 hour shifts) | 7d | 2004-03-01 08:00 | 2004-03-07 17:00 | 72 | 2004-03-01 08:00 | 2004-03-07 17:00 | 7d | 0d |  | start no earlier than 2004-03-01 08:00 |
